# Projekt_jo_02_03

Schedule from MS Project, 2008-10-27 to 2008-12-17, status date 2008-11-24, costs in Ft, A marks actual dates.
iqjb

## Calendars

- Szabványos: Mon-Sun 09:00-12:00, 12:30-17:30.

## Resources

| Resource | Unit | Rate |
| --- | --- | --- |
| Á hálózatépítő 1 |  | 1500 |
| Á műszaki informatikus 1 |  | 1500 |
| Á adminisztrátor 1 |  | 1000 |
| Kovács Anita |  | 6000 |
| Kiss Attila |  | 10000 |
| Nagy Annamária |  | 1200 |
| Paál Anikó |  | 1300 |
| Kiss Anett |  | 800 |
| Rétlaki Géza |  | 1400 |
| Mároki Teréz |  | 1400 |
| Mosolygó Ferenc |  | 1600 |
| Téglás Csaba |  | 1200 |
| Podorek Paula |  | 800 |
| Tiefenghalter Eszter |  | 1200 |
| Szakócza István |  | 1700 |
| Késmárki Lilla |  | 1500 |
| Á hálózatépítő 2 |  | 1500 |
| Á műszaki informatikus 2 |  | 1500 |
| Á adminisztrátor 2 |  | 1000 |
| Á műszaki informatikus 3 |  | 1500 |
| Á adminisztrátor 3 |  | 1000 |
| Á adminisztrátor 4 |  | 1000 |
| Számítógép beszerzési költségek | eFt | 1000 |
| Hálózatépítés költségei | eFt | 1000 |
| Egyéb költségek | eFt | 1000 |
| Szoftverköltségek | eFt | 1000 |
| Á programozó 1 |  |  |
| Á programozó 2 |  |  |
| Á_projektmenedzser |  | 6000 |
| Á oktató 1 |  | 4000 |
| Á oktató 2 |  | 4000 |
| Á oktató 3 |  | 4000 |
| Á műszaki informatikus 4 |  | 1500 |
| Kő Pál |  | 1200 |
| Kiss Irén |  | 1200 |
| Nagy Armand |  | 1200 |
| Beke Botond |  | 1200 |
| Kőváry Laura |  | 1200 |
| Kőpataki Tihamér |  | 2100 |
| Baumgartner Karina |  |  |
| Mathiugasz Gitisz |  | 6000 |
| László Róbert |  | 5000 |

## Schedule

| ID | WBS | Task | Type | Duration | Start | Finish | Predecessors | Complete | Remaining | Baseline start | Baseline finish | Baseline duration | Total slack | Free slack | Constraint | Deadline | Resources | Work | Actual work | Cost | Baseline cost | Actual cost | Text29 | nap, óra |
| --- | --- | --- | --- | --- | --- | --- | --- | --- | --- | --- | --- | --- | --- | --- | --- | --- | --- | --- | --- | --- | --- | --- | --- | --- |
| 1 | 1 | Célmeghatározás |  | 6.5d | 2008-10-27 A | 2008-11-02 A |  | 100% |  | 2008-10-27 | 2008-11-02 | 6.5d |  |  |  |  |  |  |  |  |  |  | 480 | 6 n, 4 ó |
| 2 | 2 | Hálózatfejlesztés |  | 9d | 2008-11-02 A | 2008-11-11 A | 1 | 100% |  | 2008-11-02 | 2008-11-13 | 11d |  |  |  |  |  |  |  |  |  |  | 480 | 9 n |
| 3 | 3 | **Betanítás** |  | 32.5d | 2008-11-08 A | 2008-12-10 |  | 27% | 23.72d | 2008-11-08 | 2008-11-28 | 20d | 7d |  |  |  |  | 440h | 200h | 1,680,000 | 1,680,000 | 720,000 | 480 | 32 n, 4 ó |
| 4 | 3.1 | **oktatók felkészítése** |  | 24.5d | 2008-11-08 A | 2008-12-02 |  | 53% | 11.61d | 2008-11-08 | 2008-11-20 | 12d | 0d |  |  |  |  | 296h | 200h | 1,104,000 | 1,104,000 | 720,000 | 480 | 24 n, 4 ó |
| 5 | 3.1.1 | oktatók betanítása |  | 4d | 2008-11-08 A | 2008-11-12 A | 2SS+6d | 100% |  | 2008-11-08 | 2008-11-12 | 4d |  |  |  |  | Á oktató 1 [50%]; Á oktató 2 [50%]; Á oktató 3 [50%]; Baumgartner Karina | 80h | 80h | 192,000 | 192,000 | 192,000 | 480 | 4 n |
| 6 | 3.1.2 | program tesztelése |  | 6d | 2008-11-09 A | 2008-11-15 A | 5SS+1d | 100% |  | 2008-11-09 | 2008-11-15 | 6d |  |  |  |  | László Róbert; Á oktató 1 [50%]; Á oktató 2 [50%]; Á oktató 3 [50%] | 120h | 120h | 528,000 | 528,000 | 528,000 | 480 | 6 n |
| 7 | 3.1.3 | látszat |  | 1d | 2008-11-25 | 2008-11-25 | 6 |  |  | 2008-11-15 | 2008-11-16 | 1d | 7d |  | start no earlier than 2008-11-24 |  |  |  |  |  |  |  | 480 | 1 n |
| 8 | 3.1.4 | jegyzet készítése |  | 8d | 2008-11-25 | 2008-12-02 | 6SS+2d, 7FF, 5 |  |  | 2008-11-12 | 2008-11-20 | 8d | 0d |  | start no earlier than 2008-11-24 |  | Á oktató 1 [50%]; Á oktató 2 [50%]; Á oktató 3 [50%] | 96h |  | 384,000 | 384,000 |  | 480 | 8 n |
| 9 | 3.1.5 | oktatók felkészítése kész | milestone | 0d | 2008-12-02 | 2008-12-02 | 8 |  |  | 2008-11-20 | 2008-11-20 | 0d | 0d |  | start no earlier than 2008-11-24 | 2008-12-05 |  |  |  |  |  |  | 480 | --mérföldkő-- |
| 10 | 3.2 | **Minőségbiztosítás részleg betanítása** |  | 8d | 2008-12-03 | 2008-12-10 |  |  |  | 2008-11-20 | 2008-11-28 | 8d | 0d |  |  |  |  | 112h |  | 448,000 | 448,000 |  | 480 | 8 n |
| 11 | 3.2.1 | csoport 1. |  | 2d | 2008-12-03 | 2008-12-04 | 2, 9 |  |  | 2008-11-20 | 2008-11-22 | 2d | 0d |  | start no earlier than 2008-11-24 |  | Á oktató 1 | 16h |  | 64,000 | 64,000 |  | 480 | 2 n |
| 12 | 3.2.2 | csoport 2. |  | 3d | 2008-12-05 | 2008-12-07 | 11 |  |  | 2008-11-22 | 2008-11-25 | 3d | 7d | 0d | start no earlier than 2008-11-24 |  | Á oktató 1 | 24h |  | 96,000 | 96,000 |  | 480 | 3 n |
| 13 | 3.2.3 | csoport 3. |  | 3d | 2008-12-08 | 2008-12-10 | 12 |  |  | 2008-11-25 | 2008-11-28 | 3d | 7d |  |  |  | Á oktató 1 | 24h |  | 96,000 | 96,000 |  | 480 | 3 n |
| 14 | 3.2.4 | csoport 1. |  | 3d | 2008-12-05 | 2008-12-07 | 11 |  |  | 2008-11-22 | 2008-11-25 | 3d | 0d |  | start no earlier than 2008-11-24 |  | Á oktató 2 | 24h |  | 96,000 | 96,000 |  | 480 | 3 n |
| 15 | 3.2.5 | csoport 2. |  | 3d | 2008-12-08 | 2008-12-10 | 14 |  |  | 2008-11-25 | 2008-11-28 | 3d | 7d |  |  |  | Á oktató 2 | 24h |  | 96,000 | 96,000 |  | 480 | 3 n |
| 16 | 3.3 | **Karbantartási részleg betanítása** |  | 2d | 2008-12-03 | 2008-12-04 |  |  |  | 2008-11-20 | 2008-11-22 | 2d | 7d |  |  |  |  | 32h |  | 128,000 | 128,000 |  | 480 | 2 n |
| 17 | 3.3.1 | csoport 1. |  | 2d | 2008-12-03 | 2008-12-04 | 11SS |  |  | 2008-11-20 | 2008-11-22 | 2d | 7d | 0d | start no earlier than 2008-11-24 |  | Á oktató 3 | 16h |  | 64,000 | 64,000 |  | 480 | 2 n |
| 18 | 3.3.2 | csoport 1. |  | 2d | 2008-12-03 | 2008-12-04 | 11SS |  |  | 2008-11-20 | 2008-11-22 | 2d | 7d | 0d | start no earlier than 2008-11-24 |  | Á oktató 2 | 16h |  | 64,000 | 64,000 |  | 480 | 2 n |
| 19 | 4 | **Adatfeltöltés** |  | 15d | 2008-12-03 | 2008-12-17 |  |  |  | 2008-11-20 | 2008-12-05 | 15d | 0d |  |  |  |  | 592h |  | 816,000 | 816,000 |  | 480 | 15 n |
| 20 | 4.1 | **Minőségbiztosítási részleg adatfeltöltés** |  | 15d | 2008-12-03 | 2008-12-17 |  |  |  | 2008-11-20 | 2008-12-05 | 15d | 0d |  |  |  |  | 352h |  | 528,000 | 528,000 |  | 480 | 15 n |
| 21 | 4.1.1 | adatfeltöltés |  | 12d | 2008-12-03 | 2008-12-14 | 11SS, 13FF-3d |  |  | 2008-11-20 | 2008-12-02 | 12d | 3d |  | start no earlier than 2008-11-24 |  | Á műszaki informatikus 1; Á műszaki informatikus 2 | 192h |  | 288,000 | 288,000 |  | 480 | 12 n |
| 22 | 4.1.2 | adatfeltöltés |  | 10d | 2008-12-08 | 2008-12-17 | 14, 15FF-2d |  |  | 2008-11-25 | 2008-12-05 | 10d | 0d |  |  |  | Á műszaki informatikus 4; Á műszaki informatikus 3 | 160h |  | 240,000 | 240,000 |  | 480 | 10 n |
| 23 | 4.2 | **Karbantartási részleg adatfeltöltés** |  | 13d | 2008-12-05 | 2008-12-17 |  |  |  | 2008-11-22 | 2008-12-05 | 13d | 0d |  |  |  |  | 240h |  | 288,000 | 288,000 |  | 480 | 13 n |
| 24 | 4.2.1 | adatfeltöltés |  | 6d | 2008-12-05 | 2008-12-10 | 17 |  |  | 2008-11-22 | 2008-11-28 | 6d | 7d |  | start no earlier than 2008-11-24 |  | Beke Botond; Kiss Irén; Kő Pál | 144h |  | 172,800 | 172,800 |  | 480 | 6 n |
| 25 | 4.2.2 | adatfeltöltés |  | 6d | 2008-12-05 | 2008-12-10 | 18 |  |  | 2008-11-22 | 2008-11-28 | 6d | 7d |  | start no earlier than 2008-11-24 |  | Kőváry Laura; Nagy Armand | 96h |  | 115,200 | 115,200 |  | 480 | 6 n |
| 26 | 4.2.3 | adatfeltöltés kész | milestone | 0d | 2008-12-17 | 2008-12-17 | 21, 22, 24, 25 |  |  | 2008-12-05 | 2008-12-05 | 0d | 0d |  |  |  |  |  |  |  |  |  | 480 | --mérföldkő-- |
