# Projekt_jo_02_03

Schedule from MS Project, 2008-10-27 to 2008-12-10, status date 2008-08-29, costs in Ft.
iqjb

## Calendars

- Szabványos: Mon-Fri 08:00-12:00, 13:00-17:00; Sat-Sun off.

## Resources

| Resource | Unit | Rate |
| --- | --- | --- |
| Á hálózatépítő 1 |  | 1500 |
| Á műszaki informatikus 1 |  | 1500 |
| Á adminisztrátor 1 |  | 1000 |
| Kovács Anita |  | 6000 |
| Kiss Attila |  | 10000 |
| Nagy Annamária |  | 1200 |
| Paál Anikó |  | 1300 |
| Kiss Anett |  | 800 |
| Rétlaki Géza |  | 1400 |
| Mároki Teréz |  | 1400 |
| Mosolygó Ferenc |  | 1600 |
| Téglás Csaba |  | 1200 |
| Podorek Paula |  | 800 |
| Tiefenghalter Eszter |  | 1200 |
| Szakócza István |  | 1700 |
| Késmárki Lilla |  | 1500 |
| Á hálózatépítő 2 |  | 1500 |
| Á műszaki informatikus 2 |  | 1500 |
| Á adminisztrátor 2 |  | 1000 |
| Á műszaki informatikus 3 |  | 1500 |
| Á adminisztrátor 3 |  | 1000 |
| Á adminisztrátor 4 |  | 1000 |
| Számítógép beszerzési költségek | eFt | 1000 |
| Hálózatépítés költségei | eFt | 1000 |
| Egyéb költségek | eFt | 1000 |
| Szoftverköltségek | eFt | 1000 |
| Á programozó 1 |  |  |
| Á programozó 2 |  |  |
| Á_projektmenedzser |  | 6000 |
| Á oktató 1 |  | 4000 |
| Á oktató 2 |  | 4000 |
| Á oktató 3 |  | 4000 |
| Á műszaki informatikus 4 |  | 1500 |
| Kő Pál |  | 1200 |
| Kiss Irén |  | 1200 |
| Nagy Armand |  | 1200 |
| Beke Botond |  | 1200 |
| Kőváry Laura |  | 1200 |
| Kőpataki Tihamér |  | 2100 |
| Baumgartner Karina |  |  |
| Mathiugasz Gitisz |  | 6000 |

## Schedule

| ID | WBS | Task | Type | Duration | Start | Finish | Predecessors | Total slack | Free slack | Resources | Work | Cost | Text29 | nap, óra |
| --- | --- | --- | --- | --- | --- | --- | --- | --- | --- | --- | --- | --- | --- | --- |
| 1 | 1 | Célmeghatározás |  | 6.5d | 2008-10-27 | 2008-11-04 |  | 0d |  |  |  |  | 480 | 6 n, 4 ó |
| 2 | 2 | Hálózatfejlesztés |  | 11d | 2008-11-04 | 2008-11-19 | 1 | 0d |  |  |  |  | 480 | 11 n |
| 3 | 3 | **Betanítás** |  | 13d | 2008-11-12 | 2008-12-01 |  | 5d |  |  | 224h | 768,000 | 480 | 13 n |
| 4 | 3.1 | **oktatók felkészítése** |  | 4d | 2008-11-12 | 2008-11-18 |  | 16d |  |  | 80h | 192,000 | 480 | 4 n |
| 5 | 3.1.1 | oktatók betanítása |  | 4d | 2008-11-12 | 2008-11-18 | 2SS+6d | 16d |  | Á oktató 1 [50%]; Á oktató 2 [50%]; Á oktató 3 [50%]; Baumgartner Karina | 80h | 192,000 | 480 | 4 n |
| 6 | 3.2 | **Minőségbiztosítás részleg betanítása** |  | 8d | 2008-11-19 | 2008-12-01 |  | 0d |  |  | 112h | 448,000 | 480 | 8 n |
| 7 | 3.2.1 | csoport 1. |  | 2d | 2008-11-19 | 2008-11-21 | 2 | 0d |  | Á oktató 1 | 16h | 64,000 | 480 | 2 n |
| 8 | 3.2.2 | csoport 2. |  | 3d | 2008-11-21 | 2008-11-26 | 7 | 7d | 0d | Á oktató 1 | 24h | 96,000 | 480 | 3 n |
| 9 | 3.2.3 | csoport 3. |  | 3d | 2008-11-26 | 2008-12-01 | 8 | 7d |  | Á oktató 1 | 24h | 96,000 | 480 | 3 n |
| 10 | 3.2.4 | csoport 1. |  | 3d | 2008-11-21 | 2008-11-26 | 7 | 0d |  | Á oktató 2 | 24h | 96,000 | 480 | 3 n |
| 11 | 3.2.5 | csoport 2. |  | 3d | 2008-11-26 | 2008-12-01 | 10 | 7d |  | Á oktató 2 | 24h | 96,000 | 480 | 3 n |
| 12 | 3.3 | **Karbantartási részleg betanítása** |  | 2d | 2008-11-19 | 2008-11-21 |  | 7d |  |  | 32h | 128,000 | 480 | 2 n |
| 13 | 3.3.1 | csoport 1. |  | 2d | 2008-11-19 | 2008-11-21 | 7SS | 7d | 0d | Á oktató 3 | 16h | 64,000 | 480 | 2 n |
| 14 | 3.3.2 | csoport 1. |  | 2d | 2008-11-19 | 2008-11-21 | 7SS | 7d | 0d | Á oktató 2 | 16h | 64,000 | 480 | 2 n |
| 15 | 4 | **Adatfeltöltés** |  | 15d | 2008-11-19 | 2008-12-10 |  | 0d |  |  | 592h | 816,000 | 480 | 15 n |
| 16 | 4.1 | **Minőségbiztosítási részleg adatfeltöltés** |  | 15d | 2008-11-19 | 2008-12-10 |  | 0d |  |  | 352h | 528,000 | 480 | 15 n |
| 17 | 4.1.1 | adatfeltöltés |  | 12d | 2008-11-19 | 2008-12-05 | 7SS, 9FF-3d | 3d |  | Á műszaki informatikus 1; Á műszaki informatikus 2 | 192h | 288,000 | 480 | 12 n |
| 18 | 4.1.2 | adatfeltöltés |  | 10d | 2008-11-26 | 2008-12-10 | 10, 11FF-2d | 0d |  | Á műszaki informatikus 2; Á műszaki informatikus 3 | 160h | 240,000 | 480 | 10 n |
| 19 | 4.2 | **Karbantartási részleg adatfeltöltés** |  | 13d | 2008-11-21 | 2008-12-10 |  | 0d |  |  | 240h | 288,000 | 480 | 13 n |
| 20 | 4.2.1 | adatfeltöltés |  | 6d | 2008-11-21 | 2008-12-01 | 13 | 7d |  | Beke Botond; Kiss Irén; Kő Pál | 144h | 172,800 | 480 | 6 n |
| 21 | 4.2.2 | adatfeltöltés |  | 6d | 2008-11-21 | 2008-12-01 | 14 | 7d |  | Kőváry Laura; Nagy Armand | 96h | 115,200 | 480 | 6 n |
| 22 | 4.2.3 | adatfeltöltés kész | milestone | 0d | 2008-12-10 | 2008-12-10 | 17, 18, 20, 21 | 0d |  |  |  |  | 480 | --mérföldkő-- |
